# eCom

Schedule from Planner, 2019-10-19 to 2019-12-24.

## Calendars

- Vorgabe: Mon-Sat 20:00-21:00; Sun off. Exceptions (off unless hours are given): 2019-10-20 20:00-21:00, 2019-11-18.

## Resources

| Resource |
| --- |
| Robin |
| Hannes |
| Lukas |
| Hendrik |
| Danny |
| Phillip |
| Jannik |

## Schedule

| ID | WBS | Task | Type | Duration | Start | Finish | Predecessors | Complete | Constraint | Resources | Work |
| --- | --- | --- | --- | --- | --- | --- | --- | --- | --- | --- | --- |
| 1 | 1 | **Project KickOff** |  |  | 2019-10-23 | 2019-11-05 |  |  | must start on 2019-10-30 |  | 3h |
| 2 | 1.1 | Charta überarbeiten |  |  | 2019-10-23 | 2019-11-05 |  | 100% | must start on 2019-10-23 | Jannik [25%] | 3h |
| 3 | 2 | **Lastenheft** |  |  | 2019-10-23 | 2019-12-10 |  |  | must start on 2019-12-11 |  | 111h |
| 4 | 2.1 | Dokumenten Koordinierung |  |  | 2019-10-23 | 2019-11-05 |  | 100% | start no earlier than 2019-10-23 | Lukas [25%] | 3h |
| 5 | 2.2 | Artikel bestellen (Endkunde) |  |  | 2019-10-23 | 2019-11-05 |  | 100% | start no earlier than 2019-10-23 | Phillip [34%] | 4h |
| 6 | 2.3 | Artikel bei Lieferant bestellen (Shop) |  |  | 2019-10-23 | 2019-11-05 |  | 100% | start no earlier than 2019-10-23 | Phillip [34%] | 4h |
| 7 | 2.4 | Lagerverwaltung |  |  | 2019-10-23 | 2019-11-05 |  | 100% | start no earlier than 2019-10-23 | Robin [50%] | 6h |
| 8 | 2.5 | Kundenverwaltung |  |  | 2019-10-23 | 2019-11-05 |  | 100% | start no earlier than 2019-10-23 | Hannes [50%] | 6h |
| 9 | 2.6 | Lieferantenverwaltung |  |  | 2019-10-23 | 2019-11-05 |  | 100% | start no earlier than 2019-10-23 | Hannes [50%] | 6h |
| 10 | 2.7 | Rabatt/Bonusprogramm für Endkunden |  |  | 2019-10-23 | 2019-11-05 |  | 100% | start no earlier than 2019-10-23 | Phillip [34%] | 4h |
| 11 | 2.8 | Status der Bestellung (Endkunde) |  |  | 2019-10-23 | 2019-11-05 |  | 100% | start no earlier than 2019-10-23 | Danny [50%] | 6h |
| 12 | 2.9 | Status der Lieferung an Betreiber des Shops |  |  | 2019-10-23 | 2019-11-05 |  | 100% | start no earlier than 2019-10-23 | Danny [50%] | 6h |
| 13 | 2.10 | Statistik Seite (Bestellungen, MwSt., Lagerbestände), täglich |  |  | 2019-10-23 | 2019-11-05 |  | 100% | start no earlier than 2019-10-23 | Hendrik [50%] | 6h |
| 14 | 2.11 | Einleitung, Ziel, Lieferumfang, Glosar |  |  | 2019-10-23 | 2019-11-05 |  | 100% | start no earlier than 2019-10-23 | Hendrik [50%] | 6h |
| 15 | 2.12 | Lastenheft 1. Draft | milestone | 0d | 2019-11-05 | 2019-11-05 | 14, 13, 12, 11, 10, 9, 8, 7, 6, 5, 4 |  |  |  |  |
| 16 | 2.13 | Überarbeitung Teil 1, Flussdiagramme |  |  | 2019-11-06 | 2019-11-20 | 15 | 100% |  | Robin [10%]; Hannes; Hendrik | 24h |
| 17 | 2.14 | Buchhaltung |  |  | 2019-11-20 | 2019-12-03 |  | 100% | must start on 2019-11-20 | Robin | 12h |
| 18 | 2.15 | NF Anforderungen überarbeiten |  |  | 2019-11-20 | 2019-12-03 |  | 100% | start no earlier than 2019-11-20 | Hendrik | 12h |
| 19 | 2.16 | Lastenheft änderungen umsetzen. |  |  | 2019-12-04 | 2019-12-10 |  | 100% | start no earlier than 2019-12-04 | Hendrik | 6h |
| 20 | 3 | **Glossar** |  |  | 2019-11-06 | 2019-11-12 |  |  | must start on 2019-11-13 |  | 6h |
| 21 | 3.1 | Glossar überarbeiten |  |  | 2019-11-06 | 2019-11-12 |  | 100% | start no earlier than 2019-11-06 | Lukas | 6h |
| 22 | 4 | **GUI Prototyp / Storyboards** |  |  | 2019-10-23 | 2019-12-17 |  |  | must start on 2020-02-12 |  | 72h |
| 23 | 4.1 | Webframework Technologie Recherche |  |  | 2019-10-23 | 2019-11-13 |  | 100% | start no earlier than 2019-10-23 | Jannik [66%] | 12h |
| 24 | 4.2 | Projekt Setup / Mini-Prototyp |  |  | 2019-11-13 | 2019-12-05 | 23 | 100% |  | Jannik | 18h |
| 25 | 4.3 | Liste mit Screens, welche Mockup brauchen |  |  | 2019-12-04 | 2019-12-17 |  | 62% | start no earlier than 2019-12-04 | Phillip; Jannik | 24h |
| 26 | 4.4 | Frontend Technologie Recherche (CSS) |  |  | 2019-11-06 | 2019-11-23 |  | 100% | start no earlier than 2019-11-06 | Robin [40%] | 6h |
| 27 | 4.5 | CSS weiter ausbauen |  |  | 2019-12-04 | 2019-12-17 |  | 75% | start no earlier than 2019-12-04 | Robin | 12h |

| ID | WBS | Task | Start | Finish | Predecessors | Complete | Constraint | Resources | Work |
| --- | --- | --- | --- | --- | --- | --- | --- | --- | --- |
| 28 | 5 | **Risikoanalyse** | 2019-11-06 | 2019-11-27 |  |  | must start on 2020-02-12 |  | 30h |
| 29 | 5.1 | Produktrisiken: Lagerverwaltung + Algemein | 2019-11-06 | 2019-11-20 |  | 100% | start no earlier than 2019-11-06 | Phillip [50%] | 6h |
| 30 | 5.2 | Projektrisiken | 2019-11-06 | 2019-11-20 |  | 100% | start no earlier than 2019-11-06 | Phillip [50%] | 6h |
| 31 | 5.3 | Produktrisiken: Kundenverwaltung, Lieferverwaltung, Artikelverwaltung | 2019-11-06 | 2019-11-27 |  | 100% | must start on 2019-11-06 | Danny | 18h |
| 32 | 6 | **Projektplan** | 2019-10-23 | 2019-11-20 |  |  | must start on 2020-02-12 |  | 9h |
| 33 | 6.1 | Plan überarbeiten (Gnome Planner) | 2019-11-06 | 2019-11-20 |  | 100% | start no earlier than 2019-11-06 | Robin [50%] | 6h |
| 34 | 6.2 | Recherche: Projektplannungssoftware | 2019-10-23 | 2019-11-05 |  | 100% | must start on 2019-10-23 | Robin [25%] | 3h |
| 35 | 7 | **Pflichtenheft** | 2019-11-13 | 2019-12-24 |  |  | must start on 2020-03-11 |  | 78h |
| 36 | 7.1 | Vorbereiten, Mit Vorlage vergleichen | 2019-11-20 | 2019-11-26 | 15 | 100% | start no earlier than 2019-11-20 | Hannes | 6h |
| 37 | 7.2 | Muss-Kritierien von LH ableiten | 2019-11-27 | 2019-12-10 | 36 | 100% | start no earlier than 2019-11-20 | Hannes | 12h |
| 38 | 7.3 | Muss-Kriterien ausformulieren | 2019-12-11 | 2019-12-24 | 37 |  | must start on 2019-12-11 | Hannes | 12h |
| 39 | 7.4 | Wunsch Kriterien von LH ableiten | 2019-11-27 | 2019-12-10 |  | 100% | start no earlier than 2019-11-27 | Lukas | 12h |
| 40 | 7.5 | Wunsch Kriterien ausformulieren | 2019-12-11 | 2019-12-24 |  |  | start no earlier than 2019-12-11 | Lukas | 12h |
| 41 | 7.6 | Abgrenzungskriterien | 2019-11-13 | 2019-11-27 | 15 | 100% | start no earlier than 2019-11-13 | Lukas | 12h |
| 42 | 7.7 | Produkrisiken | 2019-12-11 | 2019-12-24 | 16, 15 | 100% | start no earlier than 2019-12-11 | Hendrik | 12h |
| 43 | 8 | **Mastertestplan** | 2019-11-27 | 2019-12-10 |  |  | must start on 2020-03-11 |  | 12h |
| 44 | 8.1 | Anlegen und Beginnen | 2019-11-27 | 2019-12-10 |  | 100% | start no earlier than 2019-11-27 | Danny | 12h |
| 45 | 9 | **Systemtests** | 2019-12-11 | 2019-12-24 |  |  | must start on 2020-03-11 |  | 12h |
| 46 | 9.1 | Recherche: Teststategie für Webapps | 2019-12-11 | 2019-12-24 |  |  | start no earlier than 2019-12-11 | Danny | 12h |
| 47 | 10 | Systemtest vorbereiten | 2019-11-20 | 2019-12-03 |  | 100% | start no earlier than 2019-11-20 | Phillip | 12h |
| 48 | 11 | **Orga** | 2019-10-19 | 2019-11-05 |  |  |  |  | 9h |
| 49 | 11.1 | Infrastruktur und Wiki einrichten | 2019-10-19 | 2019-10-20 |  | 100% | must start on 2019-10-16 | Hendrik [150%] | 3h |
| 50 | 11.2 | Templates anlegen für Google Doc | 2019-10-23 | 2019-11-05 |  | 100% | start no earlier than 2019-10-23 | Robin [25%] | 3h |
| 51 | 11.3 | Recherche zu Code Formatter | 2019-10-23 | 2019-11-05 |  | 100% | must start on 2019-10-23 | Lukas [25%] | 3h |
